# vdfs

Schedule from MS Project, 2003-01-01 to 2005-01-03, scheduled back from the finish.
vista data flow system
CASU

## Calendars

- Standard: Mon-Fri 08:00-12:00, 13:00-17:00; Sat-Sun off.

## Schedule

| ID | WBS | Task | Type | Duration | Start | Finish | Baseline start | Baseline finish | Baseline duration | Total slack | Free slack | Constraint |
| --- | --- | --- | --- | --- | --- | --- | --- | --- | --- | --- | --- | --- |
| 1 | 1 | **Quarterly Reviews** |  | 461d? | 2003-03-31 | 2005-01-03 |  |  |  | 63d | 0d | as late as possible |
| 2 | 1.1 | Quarterly Review | milestone | 1d? | 2003-03-31 | 2003-03-31 |  |  |  | 63d | 0d | start no later than 2003-03-31 |
| 3 | 1.2 | Quarterly Review | milestone | 1d? | 2003-07-01 | 2003-07-01 |  |  |  | 129d | 0d | start no later than 2003-07-01 |
| 4 | 1.3 | Quarterly Review | milestone | 1d? | 2003-10-01 | 2003-10-01 |  |  |  | 195d | 0d | start no later than 2003-10-01 |
| 5 | 1.4 | Quarterly Review | milestone | 1d? | 2004-01-01 | 2004-01-01 |  |  |  | 261d | 0d | start no later than 2004-01-01 |
| 6 | 1.5 | Quarterly Review | milestone | 1d? | 2004-04-01 | 2004-04-01 |  |  |  | 326d | 0d | start no later than 2004-04-01 |
| 7 | 1.6 | Quarterly Review | milestone | 1d? | 2004-07-01 | 2004-07-01 |  |  |  | 391d | 0d | start no later than 2004-07-01 |
| 8 | 1.7 | Quarterly Review | milestone | 1d? | 2004-10-01 | 2004-10-01 |  |  |  | 457d | 0d | start no later than 2004-10-01 |
| 9 | 1.8 | Quarterly Review | milestone | 1d? | 2005-01-01 | 2005-01-03 |  |  |  | 523d | 0d | start no later than 2005-01-01 |
| 10 | 2 | **ESO VISTA software deliverables and documentation** |  | 523d? | 2003-01-01 | 2004-12-31 | 2003-01-01 | 2004-12-31 | 523d? | 0d |  | as late as possible |
| 11 | 2.1 | lots of stuff in here |  | 523d? | 2003-01-01 | 2004-12-31 | 2003-01-01 | 2004-12-31 | 523d? | 0d |  | start no later than 2003-01-01 |
| 12 | 3 | Calibration plan document | milestone | 1d? | 2003-07-01 | 2003-07-01 |  |  |  | 129d | 0d | start no later than 2003-07-01 |
| 13 | 4 | Data Reduction Specification | milestone | 1d? | 2003-07-01 | 2003-07-01 |  |  |  | 129d | 0d | start no later than 2003-07-01 |
| 14 | 5 | DFS user requirements document | milestone | 1d? | 2003-07-01 | 2003-07-01 |  |  |  | 129d | 0d | start no later than 2003-07-01 |
| 15 | 6 | **Management and Defenition of Responsibilities** |  | 523d | 2003-01-01 | 2004-12-31 | 2003-01-01 | 2003-12-31 | 261d | 0d |  | as late as possible |
| 16 | 6.1 | Report to VISTA, UKIDSS, JAC, ATC, WFAP, GSC |  | 26.15mo | 2003-01-01 | 2004-12-31 | 2003-01-01 | 2003-01-01 | 0mo | 0d |  | finish no later than 2004-12-31 |
| 17 | 6.2 | Interface Control Document between CASU and JAC |  | 26.15mo | 2003-01-01 | 2004-12-31 | 2003-12-31 | 2003-12-31 | 0mo | 0d |  | finish no later than 2004-12-31 |
| 18 | 6.3 | Interface Control Document between CASU and WFAU |  | 26.15mo | 2003-01-01 | 2004-12-31 | 2003-06-30 | 2003-06-30 | 0mo | 0d |  | finish no later than 2004-12-31 |
| 19 | 6.4 | Define data structures and FITS headers |  | 26.15mo | 2003-01-01 | 2004-12-31 | 2003-06-30 | 2003-06-30 | 0mo | 0d |  | finish no later than 2004-12-31 |
| 20 | 6.5 | Define observing protocols |  | 26.15mo | 2003-01-01 | 2004-12-31 | 2003-12-31 | 2003-12-31 | 0mo | 0d |  | finish no later than 2004-12-31 |
| 21 | 6.6 | Liaise with UKIDSS and JAC on observing strategy |  | 26.15mo | 2003-01-01 | 2004-12-31 | 2003-01-01 | 2003-01-01 | 0mo | 0d |  | finish no later than 2004-12-31 |
| 22 | 6.7 | Liaise with UKIDSS and JAC on survey planning |  | 26.15mo | 2003-01-01 | 2004-12-31 | 2003-01-01 | 2003-01-01 | 0mo | 0d |  | finish no later than 2004-12-31 |
| 23 | 6.8 | Liaise with UKIDSS and JAC on survey progress database |  | 26.15mo | 2003-01-01 | 2004-12-31 | 2003-01-01 | 2003-01-01 | 0mo | 0d |  | finish no later than 2004-12-31 |
| 24 | 7 | ICD between CASU and JAC | milestone | 1d? | 2003-12-31 | 2003-12-31 |  |  |  | 260d | 0d | start no later than 2003-12-31 |
| 25 | 8 | ICD between CASU and WFAU | milestone | 1d? | 2003-07-01 | 2003-07-01 |  |  |  | 129d | 0d | finish no later than 2003-07-01 |
| 26 | 9 | Fits headers and data structures defention document | milestone | 1d? | 2003-07-01 | 2003-07-01 |  |  |  | 129d | 0d | finish no later than 2003-07-01 |

| ID | WBS | Task | Type | Duration | Start | Finish | Predecessors | Baseline start | Baseline finish | Baseline duration | Total slack | Free slack | Constraint |
| --- | --- | --- | --- | --- | --- | --- | --- | --- | --- | --- | --- | --- | --- |
| 27 | 10 | **Pipeline Infrastructure and Progress Monitoring Tools** |  | 523d? | 2003-01-01 | 2004-12-31 |  | 2003-01-01 | 2004-12-31 | 523d? | 0d |  | as late as possible |
| 28 | 10.1 | Interactive tools for running pipeline |  | 262d? | 2003-07-01 | 2004-06-30 | 29 | 2003-07-01 | 2004-06-30 | 262d? | 0d |  | finish no later than 2004-06-30 |
| 29 | 10.2 | High level scripts to interrogate headers |  | 129d? | 2003-01-01 | 2003-06-30 |  | 2003-01-01 | 2003-06-30 | 129d? | 0d |  | finish no later than 2003-06-30 |
| 30 | 10.3 | Develop automatic progression of results to WWW pages |  | 262d? | 2003-10-01 | 2004-09-30 | 29 | 2003-10-01 | 2004-09-30 | 262d? | 66d | 0d | finish no later than 2004-09-30 |
| 31 | 10.4 | Automate checks to spot failures of pipeline |  | 262d? | 2003-10-01 | 2004-09-30 | 29 | 2003-10-01 | 2004-09-30 | 262d? | 66d | 0d | finish no later than 2004-09-30 |
| 32 | 10.5 | Tools for fixing problem datasets |  | 262d? | 2004-01-01 | 2004-12-31 |  | 2004-01-01 | 2004-12-31 | 262d? | 261d | 0d | finish no later than 2004-12-31 |
| 33 | 10.6 | Group documentation for above |  | 447.38d? | 2003-04-16 | 2004-12-31 |  | 2003-04-16 | 2004-12-31 | 447.38d? | 75.62d | 0d | finish no later than 2004-12-31 |
| 34 | 10.7 | Reprocessing after bug fixes or improvements to algorithms |  | 23d? | 2004-12-01 | 2004-12-31 |  | 2004-12-01 | 2004-12-31 | 23d? | 500d | 0d | start no later than 2004-12-01 |
| 35 | 11 | Deliver pipeline V1.0 | milestone | 1d? | 2003-12-31 | 2003-12-31 |  |  |  |  | 260d | 0d | finish no later than 2003-12-31 |
| 36 | 12 | Deliver documentation for pipeline V1.0 | milestone | 1d? | 2003-12-31 | 2003-12-31 |  |  |  |  | 260d | 0d | finish no later than 2003-12-31 |
| 37 | 13 | **Set up and Manage Raw Science Archive** |  | 328d? | 2003-10-01 | 2004-12-31 |  | 2003-10-01 | 2004-12-31 | 328d? | 195d | 0d | as late as possible |
| 38 | 13.1 | Extend current UKIRT archive to cope with WFCAM |  | 328d? | 2003-10-01 | 2004-12-31 |  | 2003-10-01 | 2004-12-31 | 328d? | 195d | 0d | start no later than 2003-10-01 |
| 39 | 13.2 | Ingest and verify WFCAM data |  | 262d? | 2004-01-01 | 2004-12-31 |  | 2004-01-01 | 2004-12-31 | 262d? | 261d | 0d | finish no later than 2004-12-31 |
| 40 | 14 | Create Raw Science Archive | milestone | 1d? | 2003-12-31 | 2003-12-31 |  |  |  |  | 260d | 0d | finish no later than 2003-12-31 |
| 41 | 15 | **Set up and Manage Data Processing System Hardware** |  | 523d? | 2003-01-01 | 2004-12-31 |  | 2003-01-01 | 2004-12-31 | 523d? | 0d |  | as late as possible |
| 42 | 15.1 | Investigate alternatives (benchmarking, reliability etc) |  | 195d? | 2003-01-01 | 2003-09-30 |  | 2003-01-01 | 2003-09-30 | 195d? | 0d |  | finish no later than 2003-09-30 |
| 43 | 15.2 | Buy hardware and install software |  | 132d? | 2003-07-01 | 2003-12-31 |  | 2003-07-01 | 2003-12-31 | 132d? | 129d | 0d | finish no later than 2003-12-31 |
| 44 | 15.3 | Integration and testing |  | 131d? | 2003-10-01 | 2004-03-31 |  | 2003-10-01 | 2004-03-31 | 131d? | 195d | 0d | finish no later than 2004-03-31 |
| 45 | 15.4 | Manage day-to-day, maintenance and upgrades |  | 262d? | 2004-01-01 | 2004-12-31 |  | 2004-01-01 | 2004-12-31 | 262d? | 261d | 0d | finish no later than 2004-12-31 |
| 46 | 15.5 | Hardware additions for further data processing system |  | 262d? | 2004-01-01 | 2004-12-31 |  | 2004-01-01 | 2004-12-31 | 262d? | 261d | 0d | finish no later than 2004-12-31 |
| 47 | 16 | Processing hardware in place | milestone | 1d? | 2003-12-31 | 2003-12-31 |  |  |  |  | 260d | 0d | finish no later than 2003-12-31 |
| 48 | 17 | **Run Standard Pipeline** |  | 262d? | 2004-01-01 | 2004-12-31 | 43 | 2004-01-01 | 2004-12-31 | 262d? | 129d | 0d | as late as possible |
| 49 | 17.1 | Ingest and verify data |  | 262d? | 2004-01-01 | 2004-12-31 |  | 2004-01-01 | 2004-12-31 | 262d? | 129d | 0d | finish no later than 2004-12-31 |
| 50 | 17.2 | Update master calibration frames |  | 262d? | 2004-01-01 | 2004-12-31 |  | 2004-01-01 | 2004-12-31 | 262d? | 129d | 0d | finish no later than 2004-12-31 |
| 51 | 17.3 | Monitor detector performance |  | 262d? | 2004-01-01 | 2004-12-31 |  | 2004-01-01 | 2004-12-31 | 262d? | 129d | 0d | finish no later than 2004-12-31 |
| 52 | 17.4 | Oversee standd processing |  | 262d? | 2004-01-01 | 2004-12-31 |  | 2004-01-01 | 2004-12-31 | 262d? | 129d | 0d | finish no later than 2004-12-31 |
| 53 | 17.5 | Astrometric calibration |  | 262d? | 2004-01-01 | 2004-12-31 |  | 2004-01-01 | 2004-12-31 | 262d? | 129d | 0d | finish no later than 2004-12-31 |
| 54 | 17.6 | Photometric calibration |  | 262d? | 2004-01-01 | 2004-12-31 |  | 2004-01-01 | 2004-12-31 | 262d? | 129d | 0d | finish no later than 2004-12-31 |
| 55 | 17.7 | Verify science products and monitor DQC measures |  | 262d? | 2004-01-01 | 2004-12-31 |  | 2004-01-01 | 2004-12-31 | 262d? | 129d | 0d | finish no later than 2004-12-31 |
| 56 | 17.8 | Monitor product data transfer to WFAU |  | 262d? | 2004-01-01 | 2004-12-31 |  | 2004-01-01 | 2004-12-31 | 262d? | 129d | 0d | finish no later than 2004-12-31 |
| 57 | 18 | Data flow to WFAU initiated | milestone | 1d? | 2004-01-01 | 2004-01-01 |  |  |  |  | 261d | 0d | finish no later than 2004-01-01 |

| ID | WBS | Task | Type | Duration | Start | Finish | Predecessors | Baseline start | Baseline finish | Baseline duration | Total slack | Free slack | Constraint | Deadline |
| --- | --- | --- | --- | --- | --- | --- | --- | --- | --- | --- | --- | --- | --- | --- |
| 58 | 19 | **Development Work for Summit Pipeline** |  | 523d? | 2003-01-01 | 2004-12-31 |  | 2003-01-01 | 2004-12-31 | 523d? | 0d |  | as late as possible |  |
| 59 | 19.1 | Interface test pipelines to ORAC-DR |  | 129d? | 2003-01-01 | 2003-06-30 |  | 2003-01-01 | 2003-06-30 | 129d? | 0d |  | finish no later than 2003-06-30 |  |
| 60 | 19.2 | Implement WFCAM pipeline at summit |  | 132d? | 2003-07-01 | 2003-12-31 | 59 | 2003-07-01 | 2003-12-31 | 132d? | 0d |  | finish no later than 2003-12-31 |  |
| 61 | 19.3 | Documentation of interface |  | 261d? | 2003-01-01 | 2003-12-31 |  | 2003-01-01 | 2003-12-31 | 261d? | 0d |  | finish no later than 2003-12-31 |  |
| 62 | 19.4 | Upgrade and maintain summit pipeline |  | 262d? | 2004-01-01 | 2004-12-31 | 60 | 2004-01-01 | 2004-12-31 | 262d? | 0d |  | finish no later than 2004-12-31 |  |
| 63 | 20 | Deliver summit pipeline | milestone | 1d? | 2003-12-31 | 2003-12-31 |  |  |  |  | 260d | 0d | finish no later than 2003-12-31 |  |
| 64 | 21 | Deliver summit pipeline documentation | milestone | 1d? | 2003-12-31 | 2003-12-31 |  |  |  |  | 260d | 0d | finish no later than 2003-12-31 |  |
| 65 | 22 | **Development and Testing of Standard 2D Processing** |  | 457d? | 2003-01-01 | 2004-09-30 |  | 2003-01-01 | 2004-09-30 | 457d? | 0d |  | as late as possible |  |
| 66 | 22.1 | Further development of standard pipeline |  | 261d? | 2003-01-01 | 2003-12-31 |  | 2003-01-01 | 2003-12-31 | 261d? | 0d |  | start no later than 2003-01-01 | 2003-12-31 |
| 67 | 22.2 | Liaison with WFCAM development team |  | 261d? | 2003-01-01 | 2003-12-31 |  | 2003-01-01 | 2003-12-31 | 261d? | 0d |  | finish no later than 2003-12-31 |  |
| 68 | 22.3 | Partake in planning commissioning observations |  | 197d? | 2003-04-01 | 2003-12-31 |  | 2003-04-01 | 2003-12-31 | 197d? | 64d | 0d | finish no later than 2003-12-31 |  |
| 69 | 22.4 | Participate directly in commissioning |  | 131d? | 2003-10-01 | 2004-03-31 |  | 2003-10-01 | 2004-03-31 | 131d? | 195d | 0d | finish no later than 2004-03-31 |  |
| 70 | 22.5 | Tuning pipeline during commissioning and after |  | 262d? | 2003-10-01 | 2004-09-30 |  | 2003-10-01 | 2004-09-30 | 262d? | 195d | 0d | finish no later than 2004-09-30 |  |
| 71 | 22.6 | Documentation of 2Dprocessing software |  | 261d? | 2003-01-01 | 2003-12-31 |  | 2003-01-01 | 2003-12-31 | 261d? | 0d |  | finish no later than 2003-12-31 |  |
| 72 | 22.7 | Comparsion between automated and manual data products |  | 261.38d? | 2003-04-01 | 2004-06-30 |  | 2003-04-01 | 2004-06-30 | 261.38d? | 64d | 0d | finish no later than 2004-06-30 |  |
| 73 | 23 | Complete 2D processing modules V1.0 | milestone | 1d? | 2003-09-30 | 2003-09-30 |  |  |  |  | 194d | 0d | finish no later than 2003-09-30 |  |
| 74 | 24 | **Development and Testing of Standard Catalogue Products** |  | 523d? | 2003-01-01 | 2004-12-31 |  | 2003-01-01 | 2004-12-31 | 523d? | 0d |  | as late as possible |  |
| 75 | 24.1 | Add in new measures requested |  | 197d? | 2003-04-01 | 2003-12-31 |  | 2003-04-01 | 2003-12-31 | 197d? | 64d | 0d | finish no later than 2003-12-31 |  |
| 76 | 24.2 | Refine astrometric calibration model |  | 394d? | 2003-07-01 | 2004-12-31 |  | 2003-07-01 | 2004-12-31 | 394d? | 129d | 0d | finish no later than 2004-12-31 |  |
| 77 | 24.3 | Generate simulations of expectd data |  | 197d? | 2003-04-01 | 2003-12-31 |  | 2003-04-01 | 2003-12-31 | 197d? | 64d | 0d | finish no later than 2003-12-31 |  |
| 78 | 24.4 | Assess catalogue parameter reliability |  | 197d? | 2003-04-01 | 2003-12-31 |  | 2003-04-01 | 2003-12-31 | 197d? | 64d | 0d | finish no later than 2003-12-31 |  |
| 79 | 24.5 | Intercomparison of catalogue products with other packages |  | 523d? | 2003-01-01 | 2004-12-31 |  | 2003-01-01 | 2004-12-31 | 523d? | 0d |  | finish no later than 2004-12-31 |  |
| 80 | 24.6 | Completeness and error estimates |  | 459d? | 2003-04-01 | 2004-12-31 |  | 2003-04-01 | 2004-12-31 | 459d? | 64d | 0d | finish no later than 2004-12-31 |  |
| 81 | 24.7 | Documentation of catalogue software and products |  | 523d? | 2003-01-01 | 2004-12-31 |  | 2003-01-01 | 2004-12-31 | 523d? | 0d |  | finish no later than 2004-12-31 |  |
| 82 | 25 | Complete standard catalogue modules V1.0 | milestone | 1d? | 2003-09-30 | 2003-09-30 |  |  |  |  | 194d | 0d | finish no later than 2003-09-30 |  |

| ID | WBS | Task | Type | Duration | Start | Finish | Predecessors | Baseline start | Baseline finish | Baseline duration | Total slack | Free slack | Constraint |
| --- | --- | --- | --- | --- | --- | --- | --- | --- | --- | --- | --- | --- | --- |
| 83 | 26 | **Set Up, Trial and Run Further Processing Software** |  | 523d? | 2003-01-01 | 2004-12-31 |  | 2003-01-01 | 2004-12-31 | 523d? | 0d |  | as late as possible |
| 84 | 26.1 | Manage and run further processing stages |  | 262d? | 2004-01-01 | 2004-12-31 |  | 2004-01-01 | 2004-12-31 | 262d? | 261d | 0d | finish no later than 2004-12-31 |
| 85 | 26.2 | Development and assessment of PSF options 1,2 |  | 523d? | 2003-01-01 | 2004-12-31 |  | 2003-01-01 | 2004-12-31 | 523d? | 0d |  | finish no later than 2004-12-31 |
| 86 | 26.3 | Develop 1D/2D PSF-deconvolved Sersic profile fits |  | 262d? | 2004-01-01 | 2004-12-31 |  | 2004-01-01 | 2004-12-31 | 262d? | 261d | 0d | finish no later than 2004-12-31 |
| 87 | 26.4 | Develop LSBG/nebulosity detection/parameterisation |  | 262d? | 2004-01-01 | 2004-12-31 |  | 2004-01-01 | 2004-12-31 | 262d? | 261d | 0d | finish no later than 2004-12-31 |
| 88 | 26.5 | Full iterative profile fitting for stellar images |  | 1d? | 2004-12-31 | 2004-12-31 |  | 2004-12-31 | 2004-12-31 | 1d? | 522d | 0d | as late as possible |
| 89 | 26.6 | Develop and optimise Bayesian image classification |  | 1d? | 2004-12-31 | 2004-12-31 |  | 2004-12-31 | 2004-12-31 | 1d? | 522d | 0d | as late as possible |
| 90 | 26.7 | Modelling and simulations of further processing steps |  | 197d? | 2004-04-01 | 2004-12-31 |  | 2004-04-01 | 2004-12-31 | 197d? | 326d | 0d | finish no later than 2004-12-31 |
| 91 | 27 | Deliver 2D PSF and Sersic fitting applications | milestone | 1d? | 2004-12-31 | 2004-12-31 |  |  |  |  | 522d | 0d | as late as possible |
| 92 | 28 | **Photometric Standards and Calibraion** |  | 523d? | 2003-01-01 | 2004-12-31 |  | 2003-01-01 | 2004-12-31 | 523d? | 0d |  | as late as possible |
| 93 | 28.1 | Agree on primary standards |  | 261d? | 2003-01-01 | 2003-12-31 |  | 2003-01-01 | 2003-12-31 | 261d? | 0d |  | finish no later than 2003-12-31 |
| 94 | 28.2 | Choose secondary standard fields |  | 261d? | 2003-01-01 | 2003-12-31 |  | 2003-01-01 | 2003-12-31 | 261d? | 0d |  | finish no later than 2003-12-31 |
| 95 | 28.3 | Take part in comissioning observations |  | 65d? | 2004-01-01 | 2004-03-31 | 93, 94 | 2004-01-01 | 2004-03-31 | 65d? | 0d |  | finish no later than 2004-03-31 |
| 96 | 28.4 | Reduce data, compute zero points and colour equations |  | 130d? | 2004-01-01 | 2004-06-30 | 93, 94 | 2004-01-01 | 2004-06-30 | 130d? | 0d |  | finish no later than 2004-06-30 |
| 97 | 28.5 | Update maintain and extend secondary standards system |  | 192d? | 2004-04-01 | 2004-12-24 | 93, 94 | 2004-04-01 | 2004-12-24 | 192d? | 65d | 0d | finish no later than 2004-12-24 |
| 98 | 28.6 | Investigate photometric calibration field systematics |  | 196d? | 2004-01-01 | 2004-09-30 | 93, 94 | 2004-01-01 | 2004-09-30 | 196d? | 0d |  | finish no later than 2004-09-30 |
| 99 | 28.7 | Assess extinction monitoring methods |  | 328d? | 2003-10-01 | 2004-12-31 |  | 2003-10-01 | 2004-12-31 | 328d? | 195d | 0d | finish no later than 2004-12-31 |
| 100 | 29 | Allocate primary and secondary standard stars/fields | milestone | 174d? | 2003-11-01 | 2004-07-01 |  |  |  |  | 218d | 0d | start no later than 2003-11-01 |
| 101 | 30 | Photometric calibration and colour equations | milestone | 1d? | 2004-07-01 | 2004-07-01 |  |  |  |  | 391d | 0d | start no later than 2004-07-01 |
| 102 | 31 | **Further Development of DQC Measures** |  | 457d? | 2003-01-01 | 2004-09-30 |  | 2003-01-01 | 2004-09-30 | 457d? | 0d |  | as late as possible |
| 103 | 31.1 | Develop extra systematic noise measures |  | 262d? | 2003-07-01 | 2004-06-30 |  | 2003-07-01 | 2004-06-30 | 262d? | 129d | 0d | finish no later than 2004-06-30 |
| 104 | 31.2 | Refine curent measures for WFCAM/VISTA data |  | 262d? | 2003-10-01 | 2004-09-30 |  | 2003-10-01 | 2004-09-30 | 262d? | 195d | 0d | finish no later than 2004-09-30 |
| 105 | 31.3 | Implement 2MASS -c.f. for throughput measures |  | 257d? | 2003-01-01 | 2004-06-28 |  | 2003-01-01 | 2004-06-28 | 257d? | 0d |  | finish no later than 2004-06-28 |
| 106 | 31.4 | Master calibration frames for detector monitoring |  | 326d? | 2003-01-01 | 2004-03-31 |  | 2003-01-01 | 2004-03-31 | 326d? | 0d |  | finish no later than 2004-03-31 |

| ID | WBS | Task | Type | Duration | Start | Finish | Baseline start | Baseline finish | Baseline duration | Total slack | Free slack | Constraint |
| --- | --- | --- | --- | --- | --- | --- | --- | --- | --- | --- | --- | --- |
| 107 | 32 | **Co-located List Driven Photometry** |  | 523d? | 2003-01-01 | 2004-12-31 | 2003-01-01 | 2004-12-31 | 523d? | 0d |  | as late as possible |
| 108 | 32.1 | Test methods for master catalogue generation |  | 129d? | 2003-01-01 | 2003-06-30 | 2003-01-01 | 2003-06-30 | 129d? | 0d |  | finish no later than 2003-06-30 |
| 109 | 32.2 | Develop basic WCS-based list driven photometer |  | 261d? | 2003-01-01 | 2003-12-31 | 2003-01-01 | 2003-12-31 | 261d? | 0d |  | finish no later than 2003-12-31 |
| 110 | 32.3 | Externally driven WCS photometry and define parameter set |  | 262d? | 2004-01-01 | 2004-12-31 | 2004-01-01 | 2004-12-31 | 262d? | 261d | 0d | finish no later than 2004-12-31 |
| 111 | 33 | Deliver list driven photometer | milestone | 1d? | 2003-12-31 | 2003-12-31 |  |  |  | 260d | 0d | finish no later than 2003-12-31 |
| 112 | 34 | **Stacking and Mosaicing** |  | 523d? | 2003-01-01 | 2004-12-31 | 2003-01-01 | 2004-12-31 | 523d? | 0d |  | as late as possible |
| 113 | 34.1 | Develop benchmark simple stacking/mosaicing framework |  | 129d? | 2003-01-01 | 2003-06-30 | 2003-01-01 | 2003-06-30 | 129d? | 0d |  | finish no later than 2003-06-30 |
| 114 | 34.2 | Nearest neighbour algorithm |  | 131d? | 2003-04-01 | 2003-09-30 | 2003-04-01 | 2003-09-30 | 131d? | 64d | 0d | finish no later than 2003-09-30 |
| 115 | 34.3 | More sophisticated rejection dealing with pixellation |  | 262d? | 2003-10-01 | 2004-09-30 | 2003-10-01 | 2004-09-30 | 262d? | 195d | 0d | finish no later than 2004-09-30 |
| 116 | 34.4 | Stacking with optimum weighting and defect rejection |  | 262d? | 2004-01-01 | 2004-12-31 | 2004-01-01 | 2004-12-31 | 262d? | 261d | 0d | finish no later than 2004-12-31 |
| 117 | 34.5 | Advanced stacking/image restoration for variable PSF |  | 1d? | 2004-12-31 | 2004-12-31 | 2004-12-31 | 2004-12-31 | 1d? | 522d | 0d | as late as possible |
| 118 | 35 | Deliver basic stacker and mosaicer | milestone | 1d? | 2003-09-30 | 2003-09-30 |  |  |  | 194d | 0d | finish no later than 2003-09-30 |
| 119 | 36 | **Continuum Subtraction and Basic Difference Imaging** |  | 457d? | 2003-01-01 | 2004-09-30 | 2003-01-01 | 2004-09-30 | 457d? | 0d |  | as late as possible |
| 120 | 36.1 | Simple WCS-based subtraction techniques |  | 196d? | 2003-04-01 | 2004-06-30 | 2003-04-01 | 2004-06-30 | 196d? | 64d | 0d | start no later than 2003-04-01 |
| 121 | 36.2 | Investigate and apply different interpolation methods |  | 326d? | 2003-01-01 | 2004-07-01 | 2003-01-01 | 2004-07-01 | 326d? | 0d |  | finish no later than 2004-07-01 |
| 122 | 36.3 | Develop adaptive kernel matching option |  | 1d | 2004-09-30 | 2004-09-30 | 2004-09-30 | 2004-09-30 | 1d | 456d | 0d | finish no later than 2004-10-01 |
| 123 | 36.4 | Transient event detection |  | 66d? | 2004-07-01 | 2004-09-30 | 2004-07-01 | 2004-09-30 | 66d? | 391d | 0d | finish no later than 2004-09-30 |
| 124 | 37 | **Interpolation Techniques and PSF Modelling** |  | 523d? | 2003-01-01 | 2004-12-31 | 2003-01-01 | 2004-12-31 | 523d? | 0d |  | as late as possible |
| 125 | 37.1 | Investigate alternative interpolation/PSF schemes |  | 129d? | 2003-01-01 | 2003-06-30 | 2003-01-01 | 2003-06-30 | 129d? | 0d |  | finish no later than 2003-06-30 |
| 126 | 37.2 | Implications for different stacking methods |  | 132d? | 2003-07-01 | 2003-12-31 | 2003-07-01 | 2003-12-31 | 132d? | 129d | 0d | finish no later than 2003-12-31 |
| 127 | 37.3 | Implications for deriving catalogues and parameters |  | 261d? | 2003-01-01 | 2003-12-31 | 2003-01-01 | 2003-12-31 | 261d? | 0d |  | finish no later than 2003-12-31 |
| 128 | 37.4 | Oversampled PSF generation per detector |  | 523d? | 2003-01-01 | 2004-12-31 | 2003-01-01 | 2004-12-31 | 523d? | 0d |  | finish no later than 2004-12-31 |
| 129 | 37.5 | Develop oversampled spatially varying PSF model |  | 262d? | 2004-01-01 | 2004-12-31 | 2004-01-01 | 2004-12-31 | 262d? | 261d | 0d | finish no later than 2004-12-31 |
| 130 | 38 | Deliver PSF photometer | milestone | 1d? | 2004-12-31 | 2004-12-31 |  |  |  | 522d | 0d | as late as possible |
